# Proyecto CRM - Corporacion Union

Schedule from MS Project, 2006-11-14 to 2007-01-19.

## Calendars

- Estándar: Mon-Fri 08:00-12:00, 13:00-17:00; Sat-Sun off. Exceptions (off unless hours are given): 2006-12-25, 2007-01-01.

## Resources

| Resource |
| --- |
| LR |
| BC-Merc |
| GS |
| BC-Sist |
| Aron |
| FA |
| AG |
| RC |
| Lore |
| BC-CG |
| AB |
| EUCV |
| Pprofit |

## Schedule

| ID | WBS | Task | Type | Duration | Start | Finish | Predecessors | Total slack | Free slack | Constraint | Resources | Work |
| --- | --- | --- | --- | --- | --- | --- | --- | --- | --- | --- | --- | --- |
| 1 | 1 | **Proyecto WebSite Egresados UCV** |  | 46.25d | 2006-11-14 | 2007-01-19 |  | 0d |  |  |  | 650h |
| 2 | 1.1 | Reunión de Arranque |  | 0.38d | 2006-11-14 | 2006-11-14 |  | 45.88d |  | start no earlier than 2006-11-14 | LR; Lore | 6h |
| 3 | 1.2 | Análsis y preparación material para definición requerimientos |  | 2d | 2006-11-20 | 2006-11-21 |  | 40.08d |  | start no earlier than 2006-11-20 | Lore [50%] | 8h |
| 4 | 1.3 | **Especificación de Requerimientos** |  | 11.5d | 2006-11-23 | 2006-12-08 |  | 27.75d |  |  |  | 64h |
| 5 | 1.3.1 | **Levantamiento de Información** |  | 4.5d | 2006-11-23 | 2006-11-29 |  | 34.75d |  |  |  | 20h |
| 6 | 1.3.1.1 | Mesa de Trabajo #1 |  | 0.5d | 2006-11-23 | 2006-11-23 |  | 38.58d |  | start no earlier than 2006-11-23 | LR; Lore; EUCV | 8h |
| 7 | 1.3.1.2 | Mesa de Trabajo #2 |  | 0.5d | 2006-11-29 | 2006-11-29 |  | 34.58d |  | start no earlier than 2006-11-29 | AB; EUCV; Lore; LR | 12h |
| 8 | 1.3.2 | Elaboración del Informe Especificación de Req. |  | 3d | 2006-11-29 | 2006-12-01 |  | 22.5d | 0d | start no earlier than 2006-11-29 | Lore [50%] | 12h |
| 9 | 1.3.3 | Entrega al Equipo de Proyecto E.UCV para su revisión | milestone | 0d | 2006-12-01 | 2006-12-01 | 8 | 14d | 0d | start no earlier than 2006-12-01 |  |  |
| 10 | 1.3.4 | Revisión por parte del Equipo de Proyecto E. UCV |  | 2d | 2006-12-04 | 2006-12-05 | 9 | 27.08d | 0d |  | EUCV | 16h |
| 11 | 1.3.5 | Recepción de ajustes recomendados al Informe | milestone | 0d | 2006-12-05 | 2006-12-05 | 10 | 27.08d | 0d |  |  |  |
| 12 | 1.3.6 | Ajustes al Informe Especificación de Requerimientos |  | 1d | 2006-12-06 | 2006-12-06 | 11 | 27.08d | 0d |  | Lore [50%] | 4h |
| 13 | 1.3.7 | Entrega de Especificación de Req. para aprobación | milestone | 0d | 2006-12-07 | 2006-12-07 | 12 | 27.08d | 0d | start no earlier than 2006-12-07 | Lore |  |
| 14 | 1.3.8 | Aprobación del Informe Especificación de Requerimientos |  | 1.5d | 2006-12-07 | 2006-12-08 | 13 | 27.08d | 0d | start no earlier than 2006-09-15 | EUCV | 12h |
| 15 | 1.3.9 | Informe Especificación de Requerimientos Aprobado | milestone | 0d | 2006-12-08 | 2006-12-08 | 14 | 27.08d | 6.5d |  |  |  |
| 16 | 1.4 | **Configuración y Desarrollo** |  | 34d | 2006-11-20 | 2007-01-08 |  | 1d |  |  |  | 338h |
| 17 | 1.4.1 | Creación estructura WiB3 para la Página Web |  | 2d | 2006-11-20 | 2006-11-21 |  | 37d |  | start no earlier than 2006-11-20 | Aron [12.5%] | 2h |
| 18 | 1.4.2 | Creación de aplicaciones en N2C |  | 2d | 2006-11-20 | 2006-11-21 |  | 37d |  | start no earlier than 2006-11-20 | Aron [12.5%] | 2h |
| 19 | 1.4.3 | **Configuración WiB3** |  | 15.34d | 2006-11-22 | 2006-12-13 |  | 24.91d |  |  |  | 58h |
| 20 | 1.4.3.1 | Migración del Sitio actual a WiB V3 |  | 10d | 2006-11-22 | 2006-12-05 |  | 24.91d | 0d | start no earlier than 2006-11-22 | FA [50%] | 40h |
| 21 | 1.4.3.2 | Presentación y aprobación a la Asociación de E. UCV |  | 0.34d | 2006-12-06 | 2006-12-06 | 20 | 24.91d | 0d |  | EUCV; FA; Lore | 6h |
| 22 | 1.4.3.3 | Ajustes sobre recomendaciones Asociacion E. UCV |  | 5d | 2006-12-06 | 2006-12-13 | 21 | 24.91d |  |  | FA [30%] | 12h |
| 23 | 1.4.4 | **Configuración Nuevas Aplicaciones** |  | 33d | 2006-11-21 | 2007-01-08 |  | 0d |  |  |  | 276h |
| 24 | 1.4.4.1 | Directorio de Egresados y Amigos de la UCV |  | 9d | 2006-11-21 | 2006-12-01 |  | 0d |  | start no earlier than 2006-11-21 | AB [55.6%] | 40h |
| 25 | 1.4.4.2 | Contáctanos |  | 6d | 2006-12-04 | 2006-12-11 | 24 | 0d |  |  | AB [50%] | 24h |
| 26 | 1.4.4.3 | Emisión de Carnets |  | 6d | 2006-12-12 | 2006-12-19 | 25 | 0d |  | start no earlier than 2006-01-31 | AB [50%] | 24h |
| 27 | 1.4.4.4 | Administración de Banners |  | 3d | 2006-12-20 | 2006-12-22 | 26 | 0d |  | start no earlier than 2006-08-21 | AB [66.7%] | 16h |
| 28 | 1.4.4.5 | Galería de Imágenes |  | 3d | 2006-12-26 | 2006-12-28 | 27 | 0d |  | start no earlier than 2006-02-13 | AB [66.7%] | 16h |
| 29 | 1.4.4.6 | Blog |  | 3d | 2006-12-29 | 2007-01-03 | 28 | 0d |  | start no earlier than 2006-02-10 | AB | 24h |
| 30 | 1.4.4.7 | Integración Profit Plus |  | 20d | 2006-11-29 | 2006-12-27 |  | 15.25d |  | start no earlier than 2006-11-29 | AB [49.6%]; LR [14.9%]; Lore [49.6%] | 108h |
| 31 | 1.4.4.8 | Definición perfiles de usuario |  | 1d | 2007-01-04 | 2007-01-04 | 29 | 0d |  |  | Lore | 8h |
| 32 | 1.4.4.9 | Pruebas internas |  | 2d | 2007-01-05 | 2007-01-08 | 31 | 11.08d |  |  | Lore | 16h |
| 33 | 1.5 | Funcionalidades de la Página Web Configuradas | milestone | 0d | 2007-01-04 | 2007-01-04 | 31 | 0d |  | start no earlier than 2006-12-19 |  |  |

Notes:
- 18: esto es la creación de las Aplicaciones por parte de Aron
- 24: Se tomó en cuenta los días de ausencia de Andrey por Graduación

| ID | WBS | Task | Type | Duration | Start | Finish | Predecessors | Total slack | Free slack | Constraint | Resources | Work |
| --- | --- | --- | --- | --- | --- | --- | --- | --- | --- | --- | --- | --- |
| 34 | 1.6 | **Plan de Pruebas** |  | 3.5d | 2006-12-19 | 2006-12-22 |  | 17.75d |  |  |  | 24h |
| 35 | 1.6.1 | Elaboración Plan de Pruebas |  | 0.5d | 2006-12-19 | 2006-12-19 | 15 | 17.5d | 0d | start no earlier than 2006-12-19 | Lore | 4h |
| 36 | 1.6.2 | Revisión Plan de Pruebas con Equipo de Trabajo |  | 2d | 2006-12-19 | 2006-12-21 | 35 | 17.5d | 0d |  | EUCV [50%]; Lore [50%] | 16h |
| 37 | 1.6.3 | Ajustes recomendados al Plan de Pruebas |  | 1d | 2006-12-21 | 2006-12-22 | 36 | 17.5d | 0d |  | Lore [50%] | 4h |
| 38 | 1.7 | Plan de Pruebas elaborado y revisado | milestone | 0d | 2006-12-22 | 2006-12-22 | 37 | 17.5d |  |  |  |  |
| 39 | 1.8 | **Pruebas de Certificación** |  | 6d | 2007-01-05 | 2007-01-12 |  | 0d |  |  |  | 43h |
| 40 | 1.8.1 | Preparación para las pruebas en ambiente de desarrollo |  | 1d | 2007-01-05 | 2007-01-05 | 33 | 0d |  | start no earlier than 2006-12-22 | Lore [25%] | 2h |
| 41 | 1.8.2 | Realización de Pruebas de Funcionalidad |  | 3d | 2007-01-08 | 2007-01-10 | 40 | 0d |  | start no earlier than 2005-07-12 | EUCV [50%]; Lore [50%] | 24h |
| 42 | 1.8.3 | Realización de Ajustes recomendados |  | 2d | 2007-01-11 | 2007-01-12 | 41 | 0d |  |  | AB [49.8%]; FA [24.9%]; Lore [31.5%] | 17h |
| 43 | 1.9 | Pruebas Certificadas | milestone | 0d | 2007-01-12 | 2007-01-12 | 42 | 0d |  |  |  |  |
| 44 | 1.10 | **Documentación** |  | 10d | 2007-01-03 | 2007-01-16 |  | 2.25d |  |  |  | 42h |
| 45 | 1.10.1 | Preparación documentos técnicos y de usuarios |  | 5d | 2007-01-04 | 2007-01-10 | 29 | 6.08d |  |  | Lore [25%] | 10h |
| 46 | 1.10.2 | Ajustes a la documentación |  | 2d | 2007-01-15 | 2007-01-16 | 43 | 2.08d |  |  | AB [50%]; Lore [25%] | 12h |
| 47 | 1.10.3 | Técnica WIB |  | 5d | 2007-01-03 | 2007-01-09 |  | 7.25d |  | start no earlier than 2007-01-03 | FA [50%] | 20h |
| 48 | 1.11 | **Adiestramiento** |  | 3d | 2007-01-10 | 2007-01-12 |  | 4.25d |  |  |  | 48h |
| 49 | 1.11.1 | WiB3 |  | 1d | 2007-01-10 | 2007-01-10 |  | 4.25d | 0d | start no earlier than 2007-01-10 | FA; Lore | 16h |
| 50 | 1.11.2 | Aplicaciones |  | 2d | 2007-01-11 | 2007-01-12 | 49 | 4.25d |  |  | AB; Lore | 32h |
| 51 | 1.12 | **Puesta en Producción** |  | 3d | 2007-01-15 | 2007-01-17 |  | 0d |  |  |  | 24h |
| 52 | 1.12.1 | Migración de aplicaciones |  | 2d | 2007-01-15 | 2007-01-16 | 43 | 0d |  |  | Aron [50%] | 8h |
| 53 | 1.12.2 | Pruebas integrales |  | 1d | 2007-01-17 | 2007-01-17 | 52 | 0d |  |  | LR; EUCV | 16h |
| 54 | 1.13 | **Gerencia de Proyecto** |  | 42d | 2006-11-14 | 2007-01-12 |  | 4.25d |  |  |  | 39h |
| 55 | 1.13.1 | Planificación |  | 18d | 2006-11-14 | 2006-12-07 |  | 28.25d |  | start no earlier than 2006-11-14 | Lore [16.7%] | 24h |
| 56 | 1.13.2 | Control y Seguimiento |  | 31d | 2006-12-01 | 2007-01-12 |  | 4.25d |  | start no earlier than 2006-12-01 | Lore [6%] | 15h |
| 57 | 1.14 | **Cierre** |  | 1.25d | 2007-01-18 | 2007-01-19 |  | 0d |  |  |  | 14h |
| 58 | 1.14.1 | Preparación Presentación Cierre de Proyecto |  | 1d | 2007-01-18 | 2007-01-18 | 53 | 0d |  | start no earlier than 2007-01-11 | Lore [83.3%]; LR [16.7%] | 8h |
| 59 | 1.14.2 | Reunión Cierre de Proyecto |  | 0.25d | 2007-01-19 | 2007-01-19 | 58 | 0d |  | start no earlier than 2007-01-15 | LR; EUCV; Lore | 6h |

Notes:
- 50: Incluye aplicaciones nuevas: / Directorio de Relacionados, Administración de Banners, Emisión de Carnets, Galería de Imágenes, Contáctanos, Blog
